# Cronograma de trabajo_Gobernación Caldas

Schedule from MS Project, 2025-04-07 to 2026-04-03.

## Calendars

- Standard: Mon-Fri 08:00-12:00, 13:00-17:00; Sat-Sun off. Exceptions (off unless hours are given): 2025-04-17 (Jueves Santo), 2025-04-18 (Viernes Santo), 2025-05-01 (Día del trabajo), 2025-06-02 (Día de la Ascensión), 2025-06-23 (Corpus Christi), 2025-06-30 (Sagrado Corazón), 2025-07-20 (Día de la Independencia), 2025-08-07 (Batalla de Boyaca), 2025-08-18 (La asunción de la Virgen), 2025-10-13 (Día de la raza), 2025-11-03 (Día de Todos los Santos), 2025-11-17 (Independencia de Cartagena), 2025-12-08 (Día de la Inmaculada Concepción), 2025-12-25 (Navidad).

## Resources

| Resource |
| --- |
| Equipo Interventoría EY |
| Equipo Gob.Caldas |
| Equipo INS |

## Schedule

| ID | WBS | Task | Type | Duration | Start | Finish | Predecessors | Total slack | Free slack | Resources | Work |
| --- | --- | --- | --- | --- | --- | --- | --- | --- | --- | --- | --- |
| 1 | 1 | **INTERVENTORÍA INTEGRAL - FASE 1 ACTUALIZACIÓN TÉCNICA Y EVOLUCIÓN FUNCIONAL ERP SAP** |  | 247d | 2025-04-07 | 2026-04-03 |  | 0d |  |  | 2920h |
| 2 | 1.1 | **FASE 0: INICIO** |  | 1d | 2025-04-07 | 2025-04-07 |  | 0d |  |  | 16h |
| 3 | 1.1.1 | Hito: Firma del acta de inicio contrato de Interventoría |  | 1d | 2025-04-07 | 2025-04-07 |  | 0d |  | Equipo Interventoría EY; Equipo Gob.Caldas | 16h |
| 4 | 1.2 | **FASE 1: PLANEACIÓN INTERVENTORÍA** |  | 25d | 2025-04-08 | 2025-05-15 |  | 221d |  |  | 368h |
| 5 | 1.2.1 | Presentación de Kick-off contrato interventoría |  | 1d | 2025-04-11 | 2025-04-11 | 3FS+3d | 259d | 0d | Equipo Interventoría EY | 8h |
| 6 | 1.2.2 | **Entregable: Cronograma y matriz detallada de entregables y obligaciones** |  | 17d | 2025-04-08 | 2025-05-05 |  | 229d |  |  | 144h |
| 7 | 1.2.2.1 | **Elaborar el entregable** |  | 3d | 2025-04-08 | 2025-04-10 |  | 229d |  |  | 24h |
| 8 | 1.2.2.1.1 | Construcción de documentos |  | 3d | 2025-04-08 | 2025-04-10 | 3 | 247d | 0d | Equipo Interventoría EY | 24h |
| 9 | 1.2.2.2 | Socialización EY |  | 1d | 2025-04-10 | 2025-04-10 | 8FS-1d | 261d |  | Equipo Interventoría EY | 8h |
| 10 | 1.2.2.3 | Primera entrega EY |  | 1d | 2025-04-11 | 2025-04-11 | 8 | 247d | 0d | Equipo Interventoría EY | 8h |
| 11 | 1.2.2.4 | Revisión (primera entrega) - GOB.CALDAS |  | 5d | 2025-04-14 | 2025-04-22 | 10 | 247d | 0d | Equipo Gob.Caldas | 40h |
| 12 | 1.2.2.5 | Ajustes EY |  | 2d | 2025-04-23 | 2025-04-24 | 11 | 247d | 0d | Equipo Interventoría EY | 16h |
| 13 | 1.2.2.6 | Segunda entrega EY | milestone | 0d | 2025-04-24 | 2025-04-24 | 12 | 247d | 0d | Equipo Interventoría EY |  |
| 14 | 1.2.2.7 | Revisión (segunda entrega) - GOB.CALDAS |  | 3d | 2025-04-25 | 2025-04-29 | 13 | 247d | 0d | Equipo Gob.Caldas | 24h |
| 15 | 1.2.2.8 | Ajustes EY |  | 2d | 2025-04-30 | 2025-05-02 | 14 | 247d | 0d | Equipo Interventoría EY | 16h |
| 16 | 1.2.2.9 | Tercera entrega EY | milestone | 0d | 2025-05-02 | 2025-05-02 | 15 | 247d | 0d | Equipo Interventoría EY |  |
| 17 | 1.2.2.10 | Generar aprobación |  | 1d | 2025-05-05 | 2025-05-05 | 16 | 247d | 0d | Equipo Gob.Caldas | 8h |
| 18 | 1.2.2.11 | Hito: Radicación productos finales | milestone | 0d | 2025-05-05 | 2025-05-05 | 17 | 247d |  | Equipo Interventoría EY |  |
| 19 | 1.2.3 | **Entregable: Plan de interventoría y anexos** |  | 22d | 2025-04-09 | 2025-05-13 |  | 221d |  |  | 168h |
| 20 | 1.2.3.1 | **Elaborar el entregable** |  | 6d | 2025-04-09 | 2025-04-16 |  | 221d |  |  | 48h |
| 21 | 1.2.3.1.1 | Construcción de documentos |  | 6d | 2025-04-09 | 2025-04-16 | 3FS+1d | 239d | 0d | Equipo Interventoría EY | 48h |
| 22 | 1.2.3.2 | Socialización EY |  | 1d | 2025-04-21 | 2025-04-21 | 21 | 239d | 0d | Equipo Interventoría EY | 8h |
| 23 | 1.2.3.3 | Primera entrega EY |  | 1d | 2025-04-23 | 2025-04-23 | 22FS+1d | 239d | 0d | Equipo Interventoría EY | 8h |
| 24 | 1.2.3.4 | Revisión (primera entrega) - GOB.CALDAS |  | 5d | 2025-04-24 | 2025-04-30 | 23 | 239d | 0d | Equipo Gob.Caldas | 40h |
| 25 | 1.2.3.5 | Ajustes EY |  | 2d | 2025-05-02 | 2025-05-05 | 24 | 239d | 0d | Equipo Interventoría EY | 16h |
| 26 | 1.2.3.6 | Segunda entrega EY | milestone | 0d | 2025-05-05 | 2025-05-05 | 25 | 239d | 0d | Equipo Interventoría EY |  |
| 27 | 1.2.3.7 | Revisión (segunda entrega) - GOB.CALDAS |  | 3d | 2025-05-06 | 2025-05-08 | 26 | 239d | 0d | Equipo Gob.Caldas | 24h |
| 28 | 1.2.3.8 | Ajustes EY |  | 2d | 2025-05-09 | 2025-05-12 | 27 | 239d | 0d | Equipo Interventoría EY | 16h |
| 29 | 1.2.3.9 | Tercera entrega EY | milestone | 0d | 2025-05-12 | 2025-05-12 | 28 | 239d | 0d | Equipo Interventoría EY |  |
| 30 | 1.2.3.10 | Generar aprobación |  | 1d | 2025-05-13 | 2025-05-13 | 29 | 239d | 0d | Equipo Gob.Caldas | 8h |
| 31 | 1.2.3.11 | Hito: Radicación productos finales | milestone | 0d | 2025-05-13 | 2025-05-13 | 30 | 239d | 0d | Equipo Interventoría EY |  |

| ID | WBS | Task | Type | Duration | Start | Finish | Predecessors | Total slack | Free slack | Resources | Work |
| --- | --- | --- | --- | --- | --- | --- | --- | --- | --- | --- | --- |
| 32 | 1.2.4 | **Empalme interventoría** |  | 21d | 2025-04-14 | 2025-05-15 |  | 221d |  |  | 48h |
| 33 | 1.2.4.1 | Sesión de entendimiento contratista INS |  | 1d | 2025-04-14 | 2025-04-14 | 5 | 259d |  | Equipo Gob.Caldas; Equipo INS; Equipo Interventoría EY | 24h |
| 34 | 1.2.4.2 | Sesión capacitación plan de interventoría (INS/GOB.CALDAS) |  | 1d | 2025-05-15 | 2025-05-15 | 31FS+1d | 239d |  | Equipo Gob.Caldas; Equipo INS; Equipo Interventoría EY | 24h |
| 35 | 1.3 | **FASE 2: EJECUCIÓN INTERVENTORÍA INTEGRAL** |  | 245d | 2025-04-08 | 2026-04-02 |  | 0d |  |  | 1984h |
| 36 | 1.3.1 | **Entregable: Informe mensual de Interventoría_MES 1 Corte abril** |  | 38d | 2025-04-08 | 2025-06-04 |  | 0d |  |  | 184h |
| 37 | 1.3.1.1 | **Elaborar el entregable** |  | 23d | 2025-04-08 | 2025-05-13 |  | 0d |  |  | 64h |
| 38 | 1.3.1.1.1 | Periodo de ejecución |  | 15d | 2025-04-08 | 2025-04-30 | 3 | 0d |  |  |  |
| 39 | 1.3.1.1.2 | Construcción de documentos |  | 8d | 2025-05-02 | 2025-05-13 | 38 | 226d | 0d | Equipo Interventoría EY | 64h |
| 40 | 1.3.1.2 | Socialización EY |  | 1d | 2025-05-14 | 2025-05-14 | 39 | 226d | 0d | Equipo Interventoría EY | 8h |
| 41 | 1.3.1.3 | Primera entrega EY |  | 1d | 2025-05-15 | 2025-05-15 | 40 | 226d | 0d | Equipo Interventoría EY | 8h |
| 42 | 1.3.1.4 | Revisión (primera entrega) - GOB.CALDAS |  | 5d | 2025-05-16 | 2025-05-22 | 41 | 226d | 0d | Equipo Gob.Caldas | 40h |
| 43 | 1.3.1.5 | Ajustes EY |  | 2d | 2025-05-23 | 2025-05-26 | 42 | 226d | 0d | Equipo Interventoría EY | 16h |
| 44 | 1.3.1.6 | Segunda entrega EY | milestone | 0d | 2025-05-26 | 2025-05-26 | 43 | 226d | 0d | Equipo Interventoría EY |  |
| 45 | 1.3.1.7 | Revisión (segunda entrega) - GOB.CALDAS |  | 3d | 2025-05-27 | 2025-05-29 | 44 | 226d | 0d | Equipo Gob.Caldas | 24h |
| 46 | 1.3.1.8 | Ajustes EY |  | 2d | 2025-05-30 | 2025-06-03 | 45 | 226d | 0d | Equipo Interventoría EY | 16h |
| 47 | 1.3.1.9 | Tercera entrega EY | milestone | 0d | 2025-06-03 | 2025-06-03 | 46 | 226d | 0d | Equipo Interventoría EY |  |
| 48 | 1.3.1.10 | Generar aprobación |  | 1d | 2025-06-04 | 2025-06-04 | 47 | 226d | 0d | Equipo Gob.Caldas | 8h |
| 49 | 1.3.1.11 | Hito: Radicación productos finales | milestone | 0d | 2025-06-04 | 2025-06-04 | 48 | 226d |  | Equipo Interventoría EY |  |
| 50 | 1.3.2 | **Entregable: Informe mensual de Interventoría_MES 2 Corte mayo** |  | 44d | 2025-05-02 | 2025-07-07 |  | 0d |  |  | 184h |
| 51 | 1.3.2.1 | **Elaborar el entregable** |  | 29d | 2025-05-02 | 2025-06-12 |  | 0d |  |  | 64h |
| 52 | 1.3.2.1.1 | Periodo de ejecución |  | 21d | 2025-05-02 | 2025-05-30 | 38 | 0d |  |  |  |
| 53 | 1.3.2.1.2 | Construcción de documentos |  | 8d | 2025-06-03 | 2025-06-12 | 52 | 205d | 0d | Equipo Interventoría EY | 64h |
| 54 | 1.3.2.2 | Socialización EY |  | 1d | 2025-06-13 | 2025-06-13 | 53 | 205d | 0d | Equipo Interventoría EY | 8h |
| 55 | 1.3.2.3 | Primera entrega EY |  | 1d | 2025-06-16 | 2025-06-16 | 54 | 205d | 0d | Equipo Interventoría EY | 8h |
| 56 | 1.3.2.4 | Revisión (primera entrega) - GOB.CALDAS |  | 5d | 2025-06-17 | 2025-06-24 | 55 | 205d | 0d | Equipo Gob.Caldas | 40h |
| 57 | 1.3.2.5 | Ajustes EY |  | 2d | 2025-06-25 | 2025-06-26 | 56 | 205d | 0d | Equipo Interventoría EY | 16h |
| 58 | 1.3.2.6 | Segunda entrega EY | milestone | 0d | 2025-06-26 | 2025-06-26 | 57 | 205d | 0d | Equipo Interventoría EY |  |
| 59 | 1.3.2.7 | Revisión (segunda entrega) - GOB.CALDAS |  | 3d | 2025-06-27 | 2025-07-02 | 58 | 205d | 0d | Equipo Gob.Caldas | 24h |
| 60 | 1.3.2.8 | Ajustes EY |  | 2d | 2025-07-03 | 2025-07-04 | 59 | 205d | 0d | Equipo Interventoría EY | 16h |
| 61 | 1.3.2.9 | Tercera entrega EY | milestone | 0d | 2025-07-04 | 2025-07-04 | 60 | 205d | 0d | Equipo Interventoría EY |  |
| 62 | 1.3.2.10 | Generar aprobación |  | 1d | 2025-07-07 | 2025-07-07 | 61 | 205d | 0d | Equipo Gob.Caldas | 8h |
| 63 | 1.3.2.11 | Hito: Radicación productos finales | milestone | 0d | 2025-07-07 | 2025-07-07 | 62 | 205d |  | Equipo Interventoría EY |  |

| ID | WBS | Task | Type | Duration | Start | Finish | Predecessors | Total slack | Free slack | Resources | Work |
| --- | --- | --- | --- | --- | --- | --- | --- | --- | --- | --- | --- |
| 64 | 1.3.3 | **Entregable: Informe mensual de Interventoría_MES 3 Corte Junio** |  | 42d | 2025-06-03 | 2025-08-01 |  | 0d |  |  | 192h |
| 65 | 1.3.3.1 | **Elaborar el entregable** |  | 27d | 2025-06-03 | 2025-07-11 |  | 0d |  |  | 72h |
| 66 | 1.3.3.1.1 | Periodo de ejecución |  | 18d | 2025-06-03 | 2025-06-27 | 52 | 0d |  |  |  |
| 67 | 1.3.3.1.2 | Construcción de documentos |  | 9d | 2025-07-01 | 2025-07-11 | 66 | 186d | 0d | Equipo Interventoría EY | 72h |
| 68 | 1.3.3.2 | Socialización EY |  | 1d | 2025-07-14 | 2025-07-14 | 67 | 186d | 0d | Equipo Interventoría EY | 8h |
| 69 | 1.3.3.3 | Primera entrega EY |  | 1d | 2025-07-15 | 2025-07-15 | 68 | 186d | 0d | Equipo Interventoría EY | 8h |
| 70 | 1.3.3.4 | Revisión (primera entrega) - GOB.CALDAS |  | 5d | 2025-07-16 | 2025-07-22 | 69 | 186d | 0d | Equipo Gob.Caldas | 40h |
| 71 | 1.3.3.5 | Ajustes EY |  | 2d | 2025-07-23 | 2025-07-24 | 70 | 186d | 0d | Equipo Interventoría EY | 16h |
| 72 | 1.3.3.6 | Segunda entrega EY | milestone | 0d | 2025-07-24 | 2025-07-24 | 71 | 186d | 0d | Equipo Interventoría EY |  |
| 73 | 1.3.3.7 | Revisión (segunda entrega) - GOB.CALDAS |  | 3d | 2025-07-25 | 2025-07-29 | 72 | 186d | 0d | Equipo Gob.Caldas | 24h |
| 74 | 1.3.3.8 | Ajustes EY |  | 2d | 2025-07-30 | 2025-07-31 | 73 | 186d | 0d | Equipo Interventoría EY | 16h |
| 75 | 1.3.3.9 | Tercera entrega EY | milestone | 0d | 2025-07-31 | 2025-07-31 | 74 | 186d | 0d | Equipo Interventoría EY |  |
| 76 | 1.3.3.10 | Generar aprobación |  | 1d | 2025-08-01 | 2025-08-01 | 75 | 186d | 0d | Equipo Gob.Caldas | 8h |
| 77 | 1.3.3.11 | Hito: Radicación productos finales | milestone | 0d | 2025-08-01 | 2025-08-01 | 76 | 186d |  | Equipo Interventoría EY |  |
| 78 | 1.3.4 | **Entregable: Informe mensual de Interventoría_MES 4 Corte julio** |  | 46d | 2025-07-01 | 2025-09-04 |  | 0d |  |  | 184h |
| 79 | 1.3.4.1 | **Elaborar el entregable** |  | 31d | 2025-07-01 | 2025-08-13 |  | 0d |  |  | 64h |
| 80 | 1.3.4.1.1 | Periodo de ejecución |  | 23d | 2025-07-01 | 2025-07-31 | 66 | 0d |  |  |  |
| 81 | 1.3.4.1.2 | Construcción de documentos |  | 8d | 2025-08-01 | 2025-08-13 | 80 | 164d | 0d | Equipo Interventoría EY | 64h |
| 82 | 1.3.4.2 | Socialización EY |  | 1d | 2025-08-14 | 2025-08-14 | 81 | 164d | 0d | Equipo Interventoría EY | 8h |
| 83 | 1.3.4.3 | Primera entrega EY |  | 1d | 2025-08-15 | 2025-08-15 | 82 | 164d | 0d | Equipo Interventoría EY | 8h |
| 84 | 1.3.4.4 | Revisión (primera entrega) - GOB.CALDAS |  | 5d | 2025-08-19 | 2025-08-25 | 83 | 164d | 0d | Equipo Gob.Caldas | 40h |
| 85 | 1.3.4.5 | Ajustes EY |  | 2d | 2025-08-26 | 2025-08-27 | 84 | 164d | 0d | Equipo Interventoría EY | 16h |
| 86 | 1.3.4.6 | Segunda entrega EY | milestone | 0d | 2025-08-27 | 2025-08-27 | 85 | 164d | 0d | Equipo Interventoría EY |  |
| 87 | 1.3.4.7 | Revisión (segunda entrega) - GOB.CALDAS |  | 3d | 2025-08-28 | 2025-09-01 | 86 | 164d | 0d | Equipo Gob.Caldas | 24h |
| 88 | 1.3.4.8 | Ajustes EY |  | 2d | 2025-09-02 | 2025-09-03 | 87 | 164d | 0d | Equipo Interventoría EY | 16h |
| 89 | 1.3.4.9 | Tercera entrega EY | milestone | 0d | 2025-09-03 | 2025-09-03 | 88 | 164d | 0d | Equipo Interventoría EY |  |
| 90 | 1.3.4.10 | Generar aprobación |  | 1d | 2025-09-04 | 2025-09-04 | 89 | 164d | 0d | Equipo Gob.Caldas | 8h |
| 91 | 1.3.4.11 | Hito: Radicación productos finales | milestone | 0d | 2025-09-04 | 2025-09-04 | 90 | 164d |  | Equipo Interventoría EY |  |

| ID | WBS | Task | Type | Duration | Start | Finish | Predecessors | Total slack | Free slack | Resources | Work |
| --- | --- | --- | --- | --- | --- | --- | --- | --- | --- | --- | --- |
| 92 | 1.3.5 | **Entregable: Informe mensual de Interventoría_MES 5 Corte agosto** |  | 43d | 2025-08-01 | 2025-10-02 |  | 0d |  |  | 192h |
| 93 | 1.3.5.1 | **Elaborar el entregable** |  | 28d | 2025-08-01 | 2025-09-11 |  | 0d |  |  | 72h |
| 94 | 1.3.5.1.1 | Periodo de ejecución |  | 19d | 2025-08-01 | 2025-08-29 | 80 | 0d |  |  |  |
| 95 | 1.3.5.1.2 | Construcción de documentos |  | 9d | 2025-09-01 | 2025-09-11 | 94 | 144d | 0d | Equipo Interventoría EY | 72h |
| 96 | 1.3.5.2 | Socialización EY |  | 1d | 2025-09-12 | 2025-09-12 | 95 | 144d | 0d | Equipo Interventoría EY | 8h |
| 97 | 1.3.5.3 | Primera entrega EY |  | 1d | 2025-09-15 | 2025-09-15 | 96 | 144d | 0d | Equipo Interventoría EY | 8h |
| 98 | 1.3.5.4 | Revisión (primera entrega) - GOB.CALDAS |  | 5d | 2025-09-16 | 2025-09-22 | 97 | 144d | 0d | Equipo Gob.Caldas | 40h |
| 99 | 1.3.5.5 | Ajustes EY |  | 2d | 2025-09-23 | 2025-09-24 | 98 | 144d | 0d | Equipo Interventoría EY | 16h |
| 100 | 1.3.5.6 | Segunda entrega EY | milestone | 0d | 2025-09-24 | 2025-09-24 | 99 | 144d | 0d | Equipo Interventoría EY |  |
| 101 | 1.3.5.7 | Revisión (segunda entrega) - GOB.CALDAS |  | 3d | 2025-09-25 | 2025-09-29 | 100 | 144d | 0d | Equipo Gob.Caldas | 24h |
| 102 | 1.3.5.8 | Ajustes EY |  | 2d | 2025-09-30 | 2025-10-01 | 101 | 144d | 0d | Equipo Interventoría EY | 16h |
| 103 | 1.3.5.9 | Tercera entrega EY | milestone | 0d | 2025-10-01 | 2025-10-01 | 102 | 144d | 0d | Equipo Interventoría EY |  |
| 104 | 1.3.5.10 | Generar aprobación |  | 1d | 2025-10-02 | 2025-10-02 | 103 | 144d | 0d | Equipo Gob.Caldas | 8h |
| 105 | 1.3.5.11 | Hito: Radicación productos finales | milestone | 0d | 2025-10-02 | 2025-10-02 | 104 | 144d |  | Equipo Interventoría EY |  |
| 106 | 1.3.6 | **Entregable: Informe mensual de Interventoría_MES 6 Corte septiembre** |  | 45d | 2025-09-01 | 2025-11-04 |  | 0d |  |  | 184h |
| 107 | 1.3.6.1 | **Elaborar el entregable** |  | 30d | 2025-09-01 | 2025-10-10 |  | 0d |  |  | 64h |
| 108 | 1.3.6.1.1 | Periodo de ejecución |  | 22d | 2025-09-01 | 2025-09-30 | 94 | 0d |  |  |  |
| 109 | 1.3.6.1.2 | Construcción de documentos |  | 8d | 2025-10-01 | 2025-10-10 | 108 | 123d | 0d | Equipo Interventoría EY | 64h |
| 110 | 1.3.6.2 | Socialización EY |  | 1d | 2025-10-14 | 2025-10-14 | 109 | 123d | 0d | Equipo Interventoría EY | 8h |
| 111 | 1.3.6.3 | Primera entrega EY |  | 1d | 2025-10-15 | 2025-10-15 | 110 | 123d | 0d | Equipo Interventoría EY | 8h |
| 112 | 1.3.6.4 | Revisión (primera entrega) - GOB.CALDAS |  | 5d | 2025-10-16 | 2025-10-22 | 111 | 123d | 0d | Equipo Gob.Caldas | 40h |
| 113 | 1.3.6.5 | Ajustes EY |  | 2d | 2025-10-23 | 2025-10-24 | 112 | 123d | 0d | Equipo Interventoría EY | 16h |
| 114 | 1.3.6.6 | Segunda entrega EY | milestone | 0d | 2025-10-24 | 2025-10-24 | 113 | 123d | 0d | Equipo Interventoría EY |  |
| 115 | 1.3.6.7 | Revisión (segunda entrega) - GOB.CALDAS |  | 3d | 2025-10-27 | 2025-10-29 | 114 | 123d | 0d | Equipo Gob.Caldas | 24h |
| 116 | 1.3.6.8 | Ajustes EY |  | 2d | 2025-10-30 | 2025-10-31 | 115 | 123d | 0d | Equipo Interventoría EY | 16h |
| 117 | 1.3.6.9 | Tercera entrega EY | milestone | 0d | 2025-10-31 | 2025-10-31 | 116 | 123d | 0d | Equipo Interventoría EY |  |
| 118 | 1.3.6.10 | Generar aprobación |  | 1d | 2025-11-04 | 2025-11-04 | 117 | 123d | 0d | Equipo Gob.Caldas | 8h |
| 119 | 1.3.6.11 | Hito: Radicación productos finales | milestone | 0d | 2025-11-04 | 2025-11-04 | 118 | 123d |  | Equipo Interventoría EY |  |

| ID | WBS | Task | Type | Duration | Start | Finish | Predecessors | Total slack | Free slack | Resources | Work |
| --- | --- | --- | --- | --- | --- | --- | --- | --- | --- | --- | --- |
| 120 | 1.3.7 | **Entregable: Informe mensual de Interventoría_MES 7 Corte Octubre** |  | 45d | 2025-10-01 | 2025-12-05 |  | 0d |  |  | 184h |
| 121 | 1.3.7.1 | **Elaborar el entregable** |  | 30d | 2025-10-01 | 2025-11-13 |  | 0d |  |  | 64h |
| 122 | 1.3.7.1.1 | Periodo de ejecución |  | 22d | 2025-10-01 | 2025-10-31 | 108 | 0d |  |  |  |
| 123 | 1.3.7.1.2 | Construcción de documentos |  | 8d | 2025-11-04 | 2025-11-13 | 122 | 82d | 0d | Equipo Interventoría EY | 64h |
| 124 | 1.3.7.2 | Socialización EY |  | 1d | 2025-11-14 | 2025-11-14 | 123 | 82d | 0d | Equipo Interventoría EY | 8h |
| 125 | 1.3.7.3 | Primera entrega EY |  | 1d | 2025-11-18 | 2025-11-18 | 124 | 82d | 0d | Equipo Interventoría EY | 8h |
| 126 | 1.3.7.4 | Revisión (primera entrega) - GOB.CALDAS |  | 5d | 2025-11-19 | 2025-11-25 | 125 | 82d | 0d | Equipo Gob.Caldas | 40h |
| 127 | 1.3.7.5 | Ajustes EY |  | 2d | 2025-11-26 | 2025-11-27 | 126 | 82d | 0d | Equipo Interventoría EY | 16h |
| 128 | 1.3.7.6 | Segunda entrega EY | milestone | 0d | 2025-11-27 | 2025-11-27 | 127 | 82d | 0d | Equipo Interventoría EY |  |
| 129 | 1.3.7.7 | Revisión (segunda entrega) - GOB.CALDAS |  | 3d | 2025-11-28 | 2025-12-02 | 128 | 82d | 0d | Equipo Gob.Caldas | 24h |
| 130 | 1.3.7.8 | Ajustes EY |  | 2d | 2025-12-03 | 2025-12-04 | 129 | 82d | 0d | Equipo Interventoría EY | 16h |
| 131 | 1.3.7.9 | Tercera entrega EY | milestone | 0d | 2025-12-04 | 2025-12-04 | 130 | 82d | 0d | Equipo Interventoría EY |  |
| 132 | 1.3.7.10 | Generar aprobación |  | 1d | 2025-12-05 | 2025-12-05 | 131 | 82d | 0d | Equipo Gob.Caldas | 8h |
| 133 | 1.3.7.11 | Hito: Radicación productos finales | milestone | 0d | 2025-12-05 | 2025-12-05 | 132 | 82d |  | Equipo Interventoría EY |  |
| 134 | 1.3.8 | **Entregable: Informe mensual de Interventoría_MES 8 Corte Noviembre** |  | 40d | 2025-11-04 | 2026-01-01 |  | 0d |  |  | 176h |
| 135 | 1.3.8.1 | **Elaborar el entregable** |  | 25d | 2025-11-04 | 2025-12-10 |  | 0d |  |  | 56h |
| 136 | 1.3.8.1.1 | Periodo de ejecución |  | 18d | 2025-11-04 | 2025-11-28 | 122 | 0d |  |  |  |
| 137 | 1.3.8.1.2 | Construcción de documentos |  | 7d | 2025-12-01 | 2025-12-10 | 136 | 65d | 0d | Equipo Interventoría EY | 56h |
| 138 | 1.3.8.2 | Socialización EY |  | 1d | 2025-12-11 | 2025-12-11 | 137 | 65d | 0d | Equipo Interventoría EY | 8h |
| 139 | 1.3.8.3 | Primera entrega EY |  | 1d | 2025-12-12 | 2025-12-12 | 138 | 65d | 0d | Equipo Interventoría EY | 8h |
| 140 | 1.3.8.4 | Revisión (primera entrega) - GOB.CALDAS |  | 5d | 2025-12-15 | 2025-12-19 | 139 | 65d | 0d | Equipo Gob.Caldas | 40h |
| 141 | 1.3.8.5 | Ajustes EY |  | 2d | 2025-12-22 | 2025-12-23 | 140 | 65d | 0d | Equipo Interventoría EY | 16h |
| 142 | 1.3.8.6 | Segunda entrega EY | milestone | 0d | 2025-12-23 | 2025-12-23 | 141 | 65d | 0d | Equipo Interventoría EY |  |
| 143 | 1.3.8.7 | Revisión (segunda entrega) - GOB.CALDAS |  | 3d | 2025-12-24 | 2025-12-29 | 142 | 65d | 0d | Equipo Gob.Caldas | 24h |
| 144 | 1.3.8.8 | Ajustes EY |  | 2d | 2025-12-30 | 2025-12-31 | 143 | 65d | 0d | Equipo Interventoría EY | 16h |
| 145 | 1.3.8.9 | Tercera entrega EY | milestone | 0d | 2025-12-31 | 2025-12-31 | 144 | 65d | 0d | Equipo Interventoría EY |  |
| 146 | 1.3.8.10 | Generar aprobación |  | 1d | 2026-01-01 | 2026-01-01 | 145 | 65d | 0d | Equipo Gob.Caldas | 8h |
| 147 | 1.3.8.11 | Hito: Radicación productos finales | milestone | 0d | 2026-01-01 | 2026-01-01 | 146 | 65d |  | Equipo Interventoría EY |  |

| ID | WBS | Task | Type | Duration | Start | Finish | Predecessors | Total slack | Free slack | Resources | Work |
| --- | --- | --- | --- | --- | --- | --- | --- | --- | --- | --- | --- |
| 148 | 1.3.9 | **Entregable: Informe de Interventoría técnica, administrativa, financiera y jurídica_cierre WAVE 1 (Modificatorio #1).** |  | 74d | 2025-12-01 | 2026-03-16 |  | 0d |  |  | 168h |
| 149 | 1.3.9.1 | **Elaborar el entregable** |  | 59d | 2025-12-01 | 2026-02-23 |  | 0d |  |  | 48h |
| 150 | 1.3.9.1.1 | Periodo de ejecución ITA |  | 53d | 2025-12-01 | 2026-02-13 | 136 | 0d |  |  |  |
| 151 | 1.3.9.1.2 | Construcción de documentos |  | 6d | 2026-02-16 | 2026-02-23 | 150 | 14d | 0d | Equipo Interventoría EY | 48h |
| 152 | 1.3.9.2 | Socialización EY |  | 1d | 2026-02-24 | 2026-02-24 | 151 | 14d | 0d | Equipo Interventoría EY | 8h |
| 153 | 1.3.9.3 | Primera entrega EY |  | 1d | 2026-02-25 | 2026-02-25 | 152 | 14d | 0d | Equipo Interventoría EY | 8h |
| 154 | 1.3.9.4 | Revisión (primera entrega) - GOB.CALDAS |  | 5d | 2026-02-26 | 2026-03-04 | 153 | 14d | 0d | Equipo Gob.Caldas | 40h |
| 155 | 1.3.9.5 | Ajustes EY |  | 2d | 2026-03-05 | 2026-03-06 | 154 | 14d | 0d | Equipo Interventoría EY | 16h |
| 156 | 1.3.9.6 | Segunda entrega EY | milestone | 0d | 2026-03-06 | 2026-03-06 | 155 | 14d | 0d | Equipo Interventoría EY |  |
| 157 | 1.3.9.7 | Revisión (segunda entrega) - GOB.CALDAS |  | 3d | 2026-03-09 | 2026-03-11 | 156 | 14d | 0d | Equipo Gob.Caldas | 24h |
| 158 | 1.3.9.8 | Ajustes EY |  | 2d | 2026-03-12 | 2026-03-13 | 157 | 14d | 0d | Equipo Interventoría EY | 16h |
| 159 | 1.3.9.9 | Tercera entrega EY | milestone | 0d | 2026-03-13 | 2026-03-13 | 158 | 14d | 0d | Equipo Interventoría EY |  |
| 160 | 1.3.9.10 | Generar aprobación |  | 1d | 2026-03-16 | 2026-03-16 | 159 | 14d | 0d | Equipo Gob.Caldas | 8h |
| 161 | 1.3.9.11 | Hito: Radicación productos finales | milestone | 0d | 2026-03-16 | 2026-03-16 | 160 | 14d |  | Equipo Interventoría EY |  |
| 162 | 1.3.10 | **Entregable: Informe de Interventoría técnica, administrativa, financiera y jurídica_cierre WAVE 2 (Modificatorio #1).** |  | 42d | 2026-02-04 | 2026-04-02 |  | 1d |  |  | 168h |
| 163 | 1.3.10.1 | **Elaborar el entregable** |  | 27d | 2026-02-04 | 2026-03-12 |  | 1d |  |  | 48h |
| 164 | 1.3.10.1.1 | Periodo de ejecución |  | 21d | 2026-02-04 | 2026-03-04 | 150FS-8d | 1d | 0d |  |  |
| 165 | 1.3.10.1.2 | Construcción de documentos |  | 6d | 2026-03-05 | 2026-03-12 | 164 | 1d | 0d | Equipo Interventoría EY | 48h |
| 166 | 1.3.10.2 | Socialización EY |  | 1d | 2026-03-13 | 2026-03-13 | 165 | 1d | 0d | Equipo Interventoría EY | 8h |
| 167 | 1.3.10.3 | Primera entrega EY |  | 1d | 2026-03-16 | 2026-03-16 | 166 | 1d | 0d | Equipo Interventoría EY | 8h |
| 168 | 1.3.10.4 | Revisión (primera entrega) - GOB.CALDAS |  | 5d | 2026-03-17 | 2026-03-23 | 167 | 1d | 0d | Equipo Gob.Caldas | 40h |
| 169 | 1.3.10.5 | Ajustes EY |  | 2d | 2026-03-24 | 2026-03-25 | 168 | 1d | 0d | Equipo Interventoría EY | 16h |
| 170 | 1.3.10.6 | Segunda entrega EY | milestone | 0d | 2026-03-25 | 2026-03-25 | 169 | 1d | 0d | Equipo Interventoría EY |  |
| 171 | 1.3.10.7 | Revisión (segunda entrega) - GOB.CALDAS |  | 3d | 2026-03-26 | 2026-03-30 | 170 | 1d | 0d | Equipo Gob.Caldas | 24h |
| 172 | 1.3.10.8 | Ajustes EY |  | 2d | 2026-03-31 | 2026-04-01 | 171 | 1d | 0d | Equipo Interventoría EY | 16h |
| 173 | 1.3.10.9 | Tercera entrega EY | milestone | 0d | 2026-04-01 | 2026-04-01 | 172 | 1d | 0d | Equipo Interventoría EY |  |
| 174 | 1.3.10.10 | Generar aprobación |  | 1d | 2026-04-02 | 2026-04-02 | 173 | 1d | 0d | Equipo Gob.Caldas | 8h |
| 175 | 1.3.10.11 | Hito: Radicación productos finales | milestone | 0d | 2026-04-02 | 2026-04-02 | 174 | 1d |  | Equipo Interventoría EY |  |

| ID | WBS | Task | Type | Duration | Start | Finish | Predecessors | Total slack | Free slack | Constraint | Resources | Work |
| --- | --- | --- | --- | --- | --- | --- | --- | --- | --- | --- | --- | --- |
| 176 | 1.3.11 | **Entregable: Informe de Interventoría técnica, administrativa, financiera y jurídica_DESPLIEGUE (Modificatorio #1).** |  | 42d | 2026-02-04 | 2026-04-02 |  | 0d |  |  |  | 168h |
| 177 | 1.3.11.1 | **Elaborar el entregable** |  | 27d | 2026-02-04 | 2026-03-12 |  | 0d |  |  |  | 48h |
| 178 | 1.3.11.1.1 | Periodo de ejecución |  | 21d | 2026-02-04 | 2026-03-04 | 150FS-8d | 0d |  |  |  |  |
| 179 | 1.3.11.1.2 | Construcción de documentos |  | 6d | 2026-03-05 | 2026-03-12 | 178 | 1d | 0d |  | Equipo Interventoría EY | 48h |
| 180 | 1.3.11.2 | Socialización EY |  | 1d | 2026-03-13 | 2026-03-13 | 179 | 1d | 0d |  | Equipo Interventoría EY | 8h |
| 181 | 1.3.11.3 | Primera entrega EY |  | 1d | 2026-03-16 | 2026-03-16 | 180 | 1d | 0d |  | Equipo Interventoría EY | 8h |
| 182 | 1.3.11.4 | Revisión (primera entrega) - GOB.CALDAS |  | 5d | 2026-03-17 | 2026-03-23 | 181 | 1d | 0d |  | Equipo Gob.Caldas | 40h |
| 183 | 1.3.11.5 | Ajustes EY |  | 2d | 2026-03-24 | 2026-03-25 | 182 | 1d | 0d |  | Equipo Interventoría EY | 16h |
| 184 | 1.3.11.6 | Segunda entrega EY | milestone | 0d | 2026-03-25 | 2026-03-25 | 183 | 1d | 0d |  | Equipo Interventoría EY |  |
| 185 | 1.3.11.7 | Revisión (segunda entrega) - GOB.CALDAS |  | 3d | 2026-03-26 | 2026-03-30 | 184 | 1d | 0d |  | Equipo Gob.Caldas | 24h |
| 186 | 1.3.11.8 | Ajustes EY |  | 2d | 2026-03-31 | 2026-04-01 | 185 | 1d | 0d |  | Equipo Interventoría EY | 16h |
| 187 | 1.3.11.9 | Tercera entrega EY | milestone | 0d | 2026-04-01 | 2026-04-01 | 186 | 1d | 0d |  | Equipo Interventoría EY |  |
| 188 | 1.3.11.10 | Generar aprobación |  | 1d | 2026-04-02 | 2026-04-02 | 187 | 1d | 0d |  | Equipo Gob.Caldas | 8h |
| 189 | 1.3.11.11 | Hito: Radicación productos finales | milestone | 0d | 2026-04-02 | 2026-04-02 | 188 | 1d |  |  | Equipo Interventoría EY |  |
| 190 | 1.4 | **FASE 3: SEGUIMIENTO Y CONTROL** |  | 238d | 2025-04-16 | 2026-04-01 |  | 2d |  |  |  | 408h |
| 191 | 1.4.1 | **Seguimiento semanal** |  | 238d | 2025-04-16 | 2026-04-01 |  | 2d |  |  |  | 408h |
| 192 | 1.4.1.1 | Seguimiento semanal 1 |  | 1d | 2025-04-16 | 2025-04-16 |  | 257d |  | start no earlier than 2025-04-16 | Equipo Interventoría EY | 8h |
| 193 | 1.4.1.2 | Seguimiento semanal 2 |  | 1d | 2025-04-23 | 2025-04-23 |  | 254d |  | start no earlier than 2025-04-23 | Equipo Interventoría EY | 8h |
| 194 | 1.4.1.3 | Seguimiento semanal 3 |  | 1d | 2025-04-30 | 2025-04-30 |  | 249d |  | start no earlier than 2025-04-30 | Equipo Interventoría EY | 8h |
| 195 | 1.4.1.4 | Seguimiento semanal 4 |  | 1d | 2025-05-07 | 2025-05-07 |  | 245d |  | start no earlier than 2025-05-07 | Equipo Interventoría EY | 8h |
| 196 | 1.4.1.5 | Seguimiento semanal 5 |  | 1d | 2025-05-14 | 2025-05-14 |  | 240d |  | start no earlier than 2025-05-14 | Equipo Interventoría EY | 8h |
| 197 | 1.4.1.6 | Seguimiento semanal 6 |  | 1d | 2025-05-21 | 2025-05-21 |  | 235d |  | start no earlier than 2025-05-21 | Equipo Interventoría EY | 8h |
| 198 | 1.4.1.7 | Seguimiento semanal 7 |  | 1d | 2025-05-28 | 2025-05-28 |  | 230d |  | start no earlier than 2025-05-28 | Equipo Interventoría EY | 8h |
| 199 | 1.4.1.8 | Seguimiento semanal 8 |  | 1d | 2025-06-04 | 2025-06-04 |  | 226d |  | start no earlier than 2025-06-04 | Equipo Interventoría EY | 8h |
| 200 | 1.4.1.9 | Seguimiento semanal 9 |  | 1d | 2025-06-11 | 2025-06-11 |  | 221d |  | start no earlier than 2025-06-11 | Equipo Interventoría EY | 8h |
| 201 | 1.4.1.10 | Seguimiento semanal 10 |  | 1d | 2025-06-18 | 2025-06-18 |  | 216d |  | start no earlier than 2025-06-18 | Equipo Interventoría EY | 8h |
| 202 | 1.4.1.11 | Seguimiento semanal 11 |  | 1d | 2025-06-25 | 2025-06-25 |  | 212d |  | start no earlier than 2025-06-25 | Equipo Interventoría EY | 8h |
| 203 | 1.4.1.12 | Seguimiento semanal 12 |  | 1d | 2025-07-02 | 2025-07-02 |  | 208d |  | start no earlier than 2025-07-02 | Equipo Interventoría EY | 8h |
| 204 | 1.4.1.13 | Seguimiento semanal 13 |  | 1d | 2025-07-09 | 2025-07-09 |  | 203d |  | start no earlier than 2025-07-09 | Equipo Interventoría EY | 8h |
| 205 | 1.4.1.14 | Seguimiento semanal 14 |  | 1d | 2025-07-16 | 2025-07-16 |  | 198d |  | start no earlier than 2025-07-16 | Equipo Interventoría EY | 8h |
| 206 | 1.4.1.15 | Seguimiento semanal 15 |  | 1d | 2025-07-23 | 2025-07-23 |  | 193d |  | start no earlier than 2025-07-23 | Equipo Interventoría EY | 8h |
| 207 | 1.4.1.16 | Seguimiento semanal 16 |  | 1d | 2025-07-30 | 2025-07-30 |  | 188d |  | start no earlier than 2025-07-30 | Equipo Interventoría EY | 8h |
| 208 | 1.4.1.17 | Seguimiento semanal 17 |  | 1d | 2025-08-06 | 2025-08-06 |  | 183d |  | start no earlier than 2025-08-06 | Equipo Interventoría EY | 8h |
| 209 | 1.4.1.18 | Seguimiento semanal 18 |  | 1d | 2025-08-13 | 2025-08-13 |  | 179d |  | start no earlier than 2025-08-13 | Equipo Interventoría EY | 8h |
| 210 | 1.4.1.19 | Seguimiento semanal 19 |  | 1d | 2025-08-20 | 2025-08-20 |  | 175d |  | start no earlier than 2025-08-20 | Equipo Interventoría EY | 8h |
| 211 | 1.4.1.20 | Seguimiento semanal 20 |  | 1d | 2025-08-27 | 2025-08-27 |  | 170d |  | start no earlier than 2025-08-27 | Equipo Interventoría EY | 8h |
| 212 | 1.4.1.21 | Seguimiento semanal 21 |  | 1d | 2025-09-03 | 2025-09-03 |  | 165d |  | start no earlier than 2025-09-03 | Equipo Interventoría EY | 8h |
| 213 | 1.4.1.22 | Seguimiento semanal 22 |  | 1d | 2025-09-10 | 2025-09-10 |  | 160d |  | start no earlier than 2025-09-10 | Equipo Interventoría EY | 8h |
| 214 | 1.4.1.23 | Seguimiento semanal 23 |  | 1d | 2025-09-17 | 2025-09-17 |  | 155d |  | start no earlier than 2025-09-17 | Equipo Interventoría EY | 8h |
| 215 | 1.4.1.24 | Seguimiento semanal 24 |  | 1d | 2025-09-24 | 2025-09-24 |  | 150d |  | start no earlier than 2025-09-24 | Equipo Interventoría EY | 8h |
| 216 | 1.4.1.25 | Seguimiento semanal 25 |  | 1d | 2025-10-01 | 2025-10-01 |  | 145d |  | start no earlier than 2025-10-01 | Equipo Interventoría EY | 8h |
| 217 | 1.4.1.26 | Seguimiento semanal 26 |  | 1d | 2025-10-08 | 2025-10-08 |  | 140d |  | start no earlier than 2025-10-08 | Equipo Interventoría EY | 8h |
| 218 | 1.4.1.27 | Seguimiento semanal 27 |  | 1d | 2025-10-15 | 2025-10-15 |  | 136d |  | start no earlier than 2025-10-15 | Equipo Interventoría EY | 8h |
| 219 | 1.4.1.28 | Seguimiento semanal 28 |  | 1d | 2025-10-22 | 2025-10-22 |  | 131d |  | start no earlier than 2025-10-22 | Equipo Interventoría EY | 8h |
| 220 | 1.4.1.29 | Seguimiento semanal 29 |  | 1d | 2025-10-29 | 2025-10-29 |  | 126d |  | start no earlier than 2025-10-29 | Equipo Interventoría EY | 8h |
| 221 | 1.4.1.30 | Seguimiento semanal 30 |  | 1d | 2025-11-05 | 2025-11-05 |  | 122d |  | start no earlier than 2025-11-05 | Equipo Interventoría EY | 8h |
| 222 | 1.4.1.31 | Seguimiento semanal 31 |  | 1d | 2025-11-12 | 2025-11-12 |  | 117d |  | start no earlier than 2025-11-12 | Equipo Interventoría EY | 8h |
| 223 | 1.4.1.32 | Seguimiento semanal 32 |  | 1d | 2025-11-19 | 2025-11-19 |  | 113d |  | start no earlier than 2025-11-19 | Equipo Interventoría EY | 8h |
| 224 | 1.4.1.33 | Seguimiento semanal 33 |  | 1d | 2025-11-26 | 2025-11-26 |  | 108d |  | start no earlier than 2025-11-26 | Equipo Interventoría EY | 8h |
| 225 | 1.4.1.34 | Seguimiento semanal 34 |  | 1d | 2025-12-03 | 2025-12-03 |  | 103d |  | start no earlier than 2025-12-03 | Equipo Interventoría EY | 8h |
| 226 | 1.4.1.35 | Seguimiento semanal 35 |  | 1d | 2025-12-10 | 2025-12-10 |  | 99d |  | start no earlier than 2025-12-10 | Equipo Interventoría EY | 8h |
| 227 | 1.4.1.36 | Seguimiento semanal 36 |  | 1d | 2025-12-17 | 2025-12-17 |  | 94d |  | start no earlier than 2025-12-17 | Equipo Interventoría EY | 8h |
| 228 | 1.4.1.37 | Seguimiento semanal 37 |  | 1d | 2025-12-24 | 2025-12-24 |  | 89d |  | start no earlier than 2025-12-24 | Equipo Interventoría EY | 8h |
| 229 | 1.4.1.38 | Seguimiento semanal 38 |  | 1d | 2025-12-31 | 2025-12-31 |  | 85d |  | start no earlier than 2025-12-31 | Equipo Interventoría EY | 8h |
| 230 | 1.4.1.39 | Seguimiento semanal 39 |  | 1d | 2026-01-07 | 2026-01-07 |  | 80d |  | start no earlier than 2026-01-07 | Equipo Interventoría EY | 8h |
| 231 | 1.4.1.40 | Seguimiento semanal 40 |  | 1d | 2026-01-14 | 2026-01-14 |  | 75d |  | start no earlier than 2026-01-14 | Equipo Interventoría EY | 8h |
| 232 | 1.4.1.41 | Seguimiento semanal 41 |  | 1d | 2026-01-21 | 2026-01-21 |  | 70d |  | start no earlier than 2026-01-21 | Equipo Interventoría EY | 8h |
| 233 | 1.4.1.42 | Seguimiento semanal 42 |  | 1d | 2026-01-28 | 2026-01-28 |  | 65d |  | start no earlier than 2026-01-28 | Equipo Interventoría EY | 8h |
| 234 | 1.4.1.43 | Seguimiento semanal 43 |  | 1d | 2026-02-04 | 2026-02-04 |  | 60d |  | start no earlier than 2026-02-04 | Equipo Interventoría EY | 8h |
| 235 | 1.4.1.44 | Seguimiento semanal 44 |  | 1d | 2026-02-11 | 2026-02-11 |  | 55d |  | start no earlier than 2026-02-11 | Equipo Interventoría EY | 8h |
| 236 | 1.4.1.45 | Seguimiento semanal 45 |  | 1d | 2026-02-18 | 2026-02-18 |  | 50d |  | start no earlier than 2026-02-18 | Equipo Interventoría EY | 8h |
| 237 | 1.4.1.46 | Seguimiento semanal 46 |  | 1d | 2026-02-25 | 2026-02-25 |  | 45d |  | start no earlier than 2026-02-25 | Equipo Interventoría EY | 8h |
| 238 | 1.4.1.47 | Seguimiento semanal 47 |  | 1d | 2026-03-04 | 2026-03-04 |  | 40d |  | start no earlier than 2026-03-04 | Equipo Interventoría EY | 8h |
| 239 | 1.4.1.48 | Seguimiento semanal 48 |  | 1d | 2026-03-11 | 2026-03-11 |  | 35d |  | start no earlier than 2026-03-11 | Equipo Interventoría EY | 8h |
| 240 | 1.4.1.49 | Seguimiento semanal 49 |  | 1d | 2026-03-18 | 2026-03-18 |  | 30d |  | start no earlier than 2026-03-18 | Equipo Interventoría EY | 8h |
| 241 | 1.4.1.50 | Seguimiento semanal 50 |  | 1d | 2026-03-25 | 2026-03-25 |  | 25d |  | start no earlier than 2026-03-25 | Equipo Interventoría EY | 8h |
| 242 | 1.4.1.51 | Seguimiento semanal 51 |  | 1d | 2026-04-01 | 2026-04-01 |  | 1d |  | start no earlier than 2026-04-01 | Equipo Interventoría EY | 8h |

| ID | WBS | Task | Type | Duration | Start | Finish | Predecessors | Total slack | Resources | Work |
| --- | --- | --- | --- | --- | --- | --- | --- | --- | --- | --- |
| 243 | 1.5 | **FASE 4: CIERRE DE LA INTERVENTORÍA** |  | 32d | 2026-02-19 | 2026-04-03 |  | 0d |  | 144h |
| 244 | 1.5.1 | **Entregable: Informe de cierre del contrato de Interventoría** |  | 32d | 2026-02-19 | 2026-04-03 |  | 0d |  | 144h |
| 245 | 1.5.1.1 | **Elaborar el entregable** |  | 19d | 2026-02-19 | 2026-03-17 |  | 0d |  | 40h |
| 246 | 1.5.1.1.1 | Periodo reportado |  | 14d | 2026-02-19 | 2026-03-10 | 178FS-10d | 0d |  |  |
| 247 | 1.5.1.1.2 | Construcción de documentos |  | 5d | 2026-03-11 | 2026-03-17 | 246 | 0d | Equipo Interventoría EY | 40h |
| 248 | 1.5.1.2 | Socialización EY |  | 1d | 2026-03-18 | 2026-03-18 | 247 | 0d | Equipo Interventoría EY | 8h |
| 249 | 1.5.1.3 | Primera entrega EY |  | 1d | 2026-03-19 | 2026-03-19 | 248 | 0d | Equipo Interventoría EY | 8h |
| 250 | 1.5.1.4 | Revisión (primera entrega) - GOB.CALDAS |  | 5d | 2026-03-20 | 2026-03-26 | 249 | 0d | Equipo Gob.Caldas | 40h |
| 251 | 1.5.1.5 | Ajustes EY |  | 1d | 2026-03-27 | 2026-03-27 | 250 | 0d | Equipo Interventoría EY | 8h |
| 252 | 1.5.1.6 | Segunda entrega EY | milestone | 0d | 2026-03-27 | 2026-03-27 | 251 | 0d | Equipo Interventoría EY |  |
| 253 | 1.5.1.7 | Revisión (segunda entrega) - GOB.CALDAS |  | 3d | 2026-03-30 | 2026-04-01 | 252 | 0d | Equipo Gob.Caldas | 24h |
| 254 | 1.5.1.8 | Ajustes EY |  | 1d | 2026-04-02 | 2026-04-02 | 253 | 0d | Equipo Interventoría EY | 8h |
| 255 | 1.5.1.9 | Tercera entrega EY | milestone | 0d | 2026-04-02 | 2026-04-02 | 254 | 0d | Equipo Interventoría EY |  |
| 256 | 1.5.1.10 | Generar aprobación |  | 1d | 2026-04-03 | 2026-04-03 | 255 | 0d | Equipo Gob.Caldas | 8h |
| 257 | 1.5.1.11 | Hito: Radicación productos finales | milestone | 0d | 2026-04-03 | 2026-04-03 | 256 | 0d | Equipo Interventoría EY |  |
