# 20260216 Plan de trabajo capacitaciones líderes

Schedule from MS Project, 2026-02-16 to 2026-03-02.

## Calendars

- Standard: Mon-Fri 08:00-12:00, 13:00-17:00; Sat-Sun off.

## Resources

| Resource |
| --- |
| Juan Zamora |
| Juan Sebastian Llano |
| Juan Zamora - GobCaldas |
| Juan Sebastian Llano - GobCaldas |
| Eduardo |
| Eduardo - GobCaldas |
| Eduardo Rivera - GobCaldas |
| Jose Miguel Alvarado - GobCaldas |
| Alfonso Reyes - GobCaldas |
| Eduardo Rivera y Mónica Gómez- GobCaldas |
| Eduardo Rivera y Mónica Gómez - GobCaldas |

## Schedule

| ID | WBS | Task | Type | Duration | Start | Finish | Predecessors | Total slack | Free slack | Constraint | Resources | Work |
| --- | --- | --- | --- | --- | --- | --- | --- | --- | --- | --- | --- | --- |
| 1 | 1 | **Capacitación a usuario final (enlaces)** |  | 10.12d | 2026-02-16 08:00 | 2026-03-02 09:00 |  | 0d |  |  |  | 67h |
| 2 | 1.1 | Hito: Fin de desatrase | milestone | 0d | 2026-02-20 08:00 | 2026-02-20 08:00 |  | 0d |  | start no earlier than 2026-02-20 08:00 |  |  |
| 3 | 1.2 | **Preparación y prerrequisitos** |  | 4d | 2026-02-16 08:00 | 2026-02-20 08:00 |  | 6.12d |  |  |  | 56h |
| 4 | 1.2.1 | Equipos de cómputo de los enlaces con sistema SAP y VPN. |  | 4d | 2026-02-16 08:00 | 2026-02-20 08:00 | 2FF | 5.12d | 0d |  | Juan Zamora - GobCaldas | 32h |
| 5 | 1.2.2 | Copia del productivo de 2026 al ambiente de pruebas. |  | 1d | 2026-02-19 08:00 | 2026-02-19 17:00 | 4FS-1d | 5.12d |  |  | Juan Zamora | 8h |
| 6 | 1.2.3 | Enviar la citación de la capacitación de presupuesto y proyectos, dos sesiones de 4 horas cada una (Una sola con educación (3) y otra sesión con los demás ()) solicitar casos a cada Enlace para el ejercicio |  | 1d | 2026-02-18 08:00 | 2026-02-18 17:00 | 2FS-2d | 6.12d |  |  | Juan Sebastian Llano - GobCaldas | 8h |
| 7 | 1.2.4 | Enviar la citación de la capacitación de MM. Solicitar casos a cada Enlace para el ejercicio |  | 1d | 2026-02-18 08:00 | 2026-02-18 17:00 | 2FS-2d | 6.12d |  |  | Juan Sebastian Llano - GobCaldas | 8h |
| 8 | 1.3 | **Capacitación presupuesto y proyectos: Sesión 1** |  | 0.45d | 2026-02-24 08:00 | 2026-02-24 11:36 |  | 0d |  |  |  | 3.6h |
| 9 | 1.3.1 | Presupuesto: Estructura de datos maestros |  | 0.4h | 2026-02-24 08:00 | 2026-02-24 08:24 | 2FS+2d | 0d |  |  | Eduardo Rivera - GobCaldas | 0.4h |
| 10 | 1.3.2 | Presupuesto: Composición del decreto de liquidación |  | 0.4h | 2026-02-24 08:24 | 2026-02-24 08:48 | 9 | 0d |  |  | Eduardo Rivera - GobCaldas | 0.4h |
| 11 | 1.3.3 | Presupuesto: Composición del plan de acción |  | 0.4h | 2026-02-24 08:48 | 2026-02-24 09:12 | 10 | 0d |  |  | Eduardo Rivera - GobCaldas | 0.4h |
| 12 | 1.3.4 | Presupuesto: Modificaciones presupuestales |  | 0.4h | 2026-02-24 09:12 | 2026-02-24 09:36 | 11 | 0d |  |  | Eduardo Rivera - GobCaldas | 0.4h |
| 13 | 1.3.5 | Presupuesto: Transacciones, generación de CDPs (por tipo de docuemento) |  | 0.4h | 2026-02-24 09:36 | 2026-02-24 10:00 | 12 | 0d |  |  | Eduardo Rivera - GobCaldas | 0.4h |
| 14 | 1.3.6 | Presupuesto: Certificado de compatibilidad |  | 0.4h | 2026-02-24 10:00 | 2026-02-24 10:24 | 13 | 0d |  |  | Eduardo Rivera - GobCaldas | 0.4h |
| 15 | 1.3.7 | Presupuesto: Generación de RPCs |  | 0.4h | 2026-02-24 10:24 | 2026-02-24 10:48 | 14 | 0d |  |  | Eduardo Rivera - GobCaldas | 0.4h |
| 16 | 1.3.8 | Proyectos: Solicitud de compatibilidad del gasto. Transacción ZPR011-1 |  | 0.4h | 2026-02-24 10:48 | 2026-02-24 11:12 | 15 | 0d |  |  | Alfonso Reyes - GobCaldas | 0.4h |
| 17 | 1.3.9 | Proyectos: Liquidación de los proyectos |  | 0.4h | 2026-02-24 11:12 | 2026-02-24 11:36 | 16 | 0d |  |  | Alfonso Reyes - GobCaldas | 0.4h |
| 18 | 1.4 | **Capacitación presupuesto y proyectos: Sesión 2** |  | 0.45d | 2026-02-25 10:48 | 2026-02-25 15:24 |  | 0d |  |  |  | 3.6h |
| 19 | 1.4.1 | Presupuesto: Estructura de datos maestros |  | 0.4h | 2026-02-25 10:48 | 2026-02-25 11:12 | 17SF+1d | 0d |  |  | Eduardo Rivera - GobCaldas | 0.4h |
| 20 | 1.4.2 | Presupuesto: Composición del decreto de liquidación |  | 0.4h | 2026-02-25 11:12 | 2026-02-25 11:36 | 19 | 0d |  |  | Eduardo Rivera - GobCaldas | 0.4h |
| 21 | 1.4.3 | Presupuesto: Composición del plan de acción |  | 0.4h | 2026-02-25 11:36 | 2026-02-25 12:00 | 20 | 0d |  |  | Eduardo Rivera - GobCaldas | 0.4h |
| 22 | 1.4.4 | Presupuesto: Modificaciones presupuestales |  | 0.4h | 2026-02-25 13:00 | 2026-02-25 13:24 | 21 | 0d |  |  | Eduardo Rivera - GobCaldas | 0.4h |
| 23 | 1.4.5 | Presupuesto: Transacciones, generación de CDPs (por tipo de docuemento) |  | 0.4h | 2026-02-25 13:24 | 2026-02-25 13:48 | 22 | 0d |  |  | Eduardo Rivera - GobCaldas | 0.4h |
| 24 | 1.4.6 | Presupuesto: Certificado de compatibilidad |  | 0.4h | 2026-02-25 13:48 | 2026-02-25 14:12 | 23 | 0d |  |  | Eduardo Rivera - GobCaldas | 0.4h |
| 25 | 1.4.7 | Presupuesto: Generación de RPCs |  | 0.4h | 2026-02-25 14:12 | 2026-02-25 14:36 | 24 | 0d |  |  | Eduardo Rivera - GobCaldas | 0.4h |
| 26 | 1.4.8 | Proyectos: Solicitud de compatibilidad del gasto. Transacción ZPR011-1 |  | 0.4h | 2026-02-25 14:36 | 2026-02-25 15:00 | 25 | 0d |  |  | Alfonso Reyes - GobCaldas | 0.4h |
| 27 | 1.4.9 | Proyectos: Liquidación de los proyectos |  | 0.4h | 2026-02-25 15:00 | 2026-02-25 15:24 | 26 | 0d |  |  | Alfonso Reyes - GobCaldas | 0.4h |

| ID | WBS | Task | Duration | Start | Finish | Predecessors | Total slack | Resources | Work |
| --- | --- | --- | --- | --- | --- | --- | --- | --- | --- |
| 28 | 1.5 | **Capacitación MM** | 0.45d | 2026-02-26 14:24 | 2026-02-27 09:00 |  | 0d |  | 3.6h |
| 29 | 1.5.1 | Solped | 0.6h | 2026-02-26 14:24 | 2026-02-26 15:00 | 27SF+1d | 0d | Jose Miguel Alvarado - GobCaldas | 0.6h |
| 30 | 1.5.2 | Contrato marco | 0.6h | 2026-02-26 15:00 | 2026-02-26 15:36 | 29 | 0d | Jose Miguel Alvarado - GobCaldas | 0.6h |
| 31 | 1.5.3 | RPCs | 0.6h | 2026-02-26 15:36 | 2026-02-26 16:12 | 30 | 0d | Jose Miguel Alvarado - GobCaldas | 0.6h |
| 32 | 1.5.4 | Entradas de mercancía | 0.6h | 2026-02-26 16:12 | 2026-02-26 16:48 | 31 | 0d | Jose Miguel Alvarado - GobCaldas | 0.6h |
| 33 | 1.5.5 | Servicios | 0.6h | 2026-02-26 16:48 | 2026-02-27 08:24 | 32 | 0d | Jose Miguel Alvarado - GobCaldas | 0.6h |
| 34 | 1.5.6 | Materiales | 0.6h | 2026-02-27 08:24 | 2026-02-27 09:00 | 33 | 0d | Jose Miguel Alvarado - GobCaldas | 0.6h |
| 35 | 1.6 | **Capacitación supervisores de contrato** | 0.03d | 2026-03-02 08:48 | 2026-03-02 09:00 |  | 0d |  | 0.2h |
| 36 | 1.6.1 | Formatos para presentación de cuentas | 0.2h | 2026-03-02 08:48 | 2026-03-02 09:00 | 34FF+1d | 0d | Eduardo Rivera y Mónica Gómez - GobCaldas | 0.2h |
